# CRONOGRAMA GANTT

Schedule from MS Project, 2022-05-02 to 2022-09-30.

## Calendars

- SEMANAL: Mon-Sat 08:00-13:00, 14:00-17:00; Sun off.

## Schedule

| ID | WBS | Task | Duration | Start | Finish | Predecessors | Total slack | Free slack |
| --- | --- | --- | --- | --- | --- | --- | --- | --- |
| 1 | 1 | **ESTRUCTURAS** | 122d | 2022-05-02 | 2022-09-20 |  | 0d |  |
| 2 | 1.1 | **OBRAS PROVISIONALES** | 19d | 2022-05-02 | 2022-05-23 |  | 9d |  |
| 3 | 1.1.1 | ALMACÉN, OFICINAS | 2d | 2022-05-02 | 2022-05-03 |  | 9d | 0d |
| 4 | 1.1.2 | CARTEL DE OBRA DE 3.60 X 2.40 m | 1d | 2022-05-02 | 2022-05-02 | 3SS | 130d |  |
| 5 | 1.1.3 | CERCO PROVISIONAL DE OBRA | 1d | 2022-05-02 | 2022-05-02 | 3SS | 130d |  |
| 6 | 1.1.4 | SERVICIOS HIGIÉNICOS | 1d | 2022-05-04 | 2022-05-04 | 3 | 128d |  |
| 7 | 1.1.5 | ELABORACION, IMPLEMENTACION Y ADMINISTRACION DEL PLAN DE SEGURIDAD Y SALUD EN EL TRABAJO | 2d | 2022-05-02 | 2022-05-03 | 3SS | 129d | 0d |
| 8 | 1.1.6 | SUMINISTRO DE DEPOSITOS DE BASURA | 1d | 2022-05-04 | 2022-05-04 | 3 | 128d |  |
| 9 | 1.1.7 | SUMINISTRO DE IMPLEMENTOS DE SEGURIDAD | 1d | 2022-05-04 | 2022-05-04 | 3 | 128d |  |
| 10 | 1.1.8 | SEÑALIZACION TEMPORAL AMBIENTAL Y SEGURIDAD | 17d | 2022-05-04 | 2022-05-23 | 3 | 112d |  |
| 11 | 1.2 | **TRABAJOS PRELIMINARES** | 122d | 2022-05-02 | 2022-09-20 |  | 9d |  |
| 12 | 1.2.1 | TRAZO Y REPLANTEO PRELIMINAR Y CONTROL PERMANENTE DE OBRA | 2d | 2022-05-04 | 2022-05-05 | 3 | 9d | 0d |
| 13 | 1.2.2 | LIMPIEZA PERMANENTE Y FINAL DE OBRA | 10d | 2022-05-04 | 2022-05-14 | 12SS | 119d |  |
| 14 | 1.2.3 | MOVILIZACION DE EQUIPO | 1d | 2022-05-04 | 2022-05-04 | 3 | 128d |  |
| 15 | 1.2.4 | **MITIGACION AMBIENTAL** | 12d | 2022-05-02 | 2022-05-14 |  | 119d |  |
| 16 | 1.2.4.1 | RIEGO DE TERRENO, MATERIAL EXCAVADO Y AGREGADOS | 10d | 2022-05-02 | 2022-05-12 | 50SS | 121d |  |
| 17 | 1.2.4.2 | PREVENCION DE DAÑOS - DERRAME DE COMBUSTIBLES | 10d | 2022-05-04 | 2022-05-14 | 3 | 119d |  |
| 18 | 1.2.5 | **DESMONTAJES** | 6d | 2022-05-04 | 2022-05-10 |  | 120d |  |
| 19 | 1.2.5.1 | DESMONTAJE DE VENTANAS | 1d | 2022-05-04 | 2022-05-04 | 12SS | 120d | 0d |
| 20 | 1.2.5.2 | DESMONTAJE DE PUERTAS | 1d | 2022-05-04 | 2022-05-04 | 19SS | 124d | 0d |
| 21 | 1.2.5.3 | DESMONTAJE DE TUBERIA DE DESAGUE | 1d | 2022-05-05 | 2022-05-05 | 19 | 120d | 0d |
| 22 | 1.2.5.4 | DESMONTAJE DE APARATOS SANITARIOS | 1d | 2022-05-05 | 2022-05-05 | 21SS | 120d | 0d |
| 23 | 1.2.5.5 | DESMONTAJE DE TANQUE ELEVADO Y SOPORTE METÁLICO | 1d | 2022-05-05 | 2022-05-05 | 21SS | 127d |  |
| 24 | 1.2.5.6 | DESMONTAJE DE COBERTURAS DE PLANCHAS DE FIBROCEMENTO (INC. LA ESTRUCTURA DE SOPORTE) | 3d | 2022-05-06 | 2022-05-09 | 22 | 120d | 0d |
| 25 | 1.2.5.7 | DESMONTAJE DE COBERTURA DE CALAMINA (INCLUYE ESTRUCTURA DE SOPORTE) | 3d | 2022-05-06 | 2022-05-09 | 24SS | 123d | 0d |
| 26 | 1.2.5.8 | DESMONTAJE DE PORTON ENTRADA PRINCIPAL | 1d | 2022-05-10 | 2022-05-10 | 25 | 123d |  |

| ID | WBS | Task | Duration | Start | Finish | Predecessors | Total slack | Free slack |
| --- | --- | --- | --- | --- | --- | --- | --- | --- |
| 27 | 1.2.6 | **DEMOLICIÓN , REMOCION Y RASQUETEO** | 7d | 2022-05-06 | 2022-05-13 |  | 120d |  |
| 28 | 1.2.6.1 | DEMOLICIÓN DE PISO INC. C.P.- F.P. | 3d | 2022-05-06 | 2022-05-09 | 22 | 120d | 0d |
| 29 | 1.2.6.2 | DEMOLICIÓN DE VEREDAS, PATIOS Y RAMPAS EXISTENTES | 4d | 2022-05-10 | 2022-05-13 | 28 | 120d |  |
| 30 | 1.2.6.3 | DEMOLICIÓN DE COLUMNAS DE CONCRETO | 1d | 2022-05-12 | 2022-05-12 | 32 | 120d | 0d |
| 31 | 1.2.6.4 | DEMOLICIÓN DE VIGAS DE CONCRETO | 1d | 2022-05-10 | 2022-05-10 | 24 | 120d | 0d |
| 32 | 1.2.6.5 | DEMOLICIÓN DE MUROS DE LADRILLO KK (SOGA Y DE CANTO) | 1d | 2022-05-11 | 2022-05-11 | 31 | 120d | 0d |
| 33 | 1.2.6.6 | DEMOLICIÓN DE CIMIENTOS DE CONCRETO | 1d | 2022-05-13 | 2022-05-13 | 30 | 120d |  |
| 34 | 1.2.7 | **DESMONTAJE DEL SISTEMA ELECTRICO** | 4d | 2022-05-05 | 2022-05-09 |  | 124d |  |
| 35 | 1.2.7.1 | DESMONTAJE DE CENTROS DE LUZ (INCLUYE INTERRUPTORES) | 1d | 2022-05-05 | 2022-05-05 | 20 | 124d | 0d |
| 36 | 1.2.7.2 | DESMONTAJE DE TOMACORRIENTES | 1d | 2022-05-06 | 2022-05-06 | 35 | 124d | 0d |
| 37 | 1.2.7.3 | DESMONTAJE DE CABLE DE CENTRO DE LUZ | 2d | 2022-05-07 | 2022-05-09 | 36 | 124d |  |
| 38 | 1.2.7.4 | DESMONTAJE DE CABLE PARA TOMACORRIENTES | 1d | 2022-05-07 | 2022-05-07 | 36 | 125d |  |
| 39 | 1.2.7.5 | DESMONTAJE DE TABLEROS | 1d | 2022-05-07 | 2022-05-07 | 36 | 125d |  |
| 40 | 1.2.8 | **PLAN PARA VIGILANCIA, PREVENCION Y CONTROL DE COVID 19, PARA EL TRABAJO** | 122d | 2022-05-02 | 2022-09-20 |  | 9d |  |
| 41 | 1.2.8.1 | ELABORACION DEL PLAN DE VIGILANCIA Y CONTROL COVID 19 | 1d | 2022-05-02 | 2022-05-02 | 7SS | 130d |  |
| 42 | 1.2.8.2 | LIMPIEZA Y DESINFECCION DE CENTRO DE TRABAJO | 120d | 2022-05-04 | 2022-09-20 | 12SS | 9d | 0d |
| 43 | 1.2.8.3 | EVALUACION DE LA CONDICION DE SALUD DEL TRABAJADOR PREVIO AL REGRESO E INCORPORACION AL CENTRO DE TRABAJO | 120d | 2022-05-04 | 2022-09-20 | 42SS | 9d | 0d |
| 44 | 1.2.8.4 | LAVADO Y DESINFECCION DE MANOS OBLIGATORIA | 120d | 2022-05-04 | 2022-09-20 | 43SS | 9d | 0d |
| 45 | 1.2.8.5 | SENSIBILIZACION DE LA PREVENCION DEL CONTAGIO EN EL CENTRO DE TRABAJO | 1d | 2022-05-04 | 2022-05-04 | 44SS | 125d | 0d |
| 46 | 1.2.8.6 | MEDIDAS PREVENTIVAS DE APLICACION COLECTIVA | 1d | 2022-05-04 | 2022-05-04 | 45SS | 125d | 0d |
| 47 | 1.2.8.7 | MEDIDAS DE PROTECCION PERSONAL | 4d | 2022-05-04 | 2022-05-07 | 46SS | 125d |  |
| 48 | 1.3 | **MOVIMIENTO DE TIERRAS** | 55d | 2022-05-02 | 2022-07-04 |  | 0d |  |
| 49 | 1.3.1 | **CORTE Y EXCAVACION** | 13d | 2022-05-02 | 2022-05-16 |  | 0d |  |
| 50 | 1.3.1.1 | EXCAVACION DE ZANJAS PARA CIMENTACION (CIMIENTOS CORRIDOS , PLATEAS Y ZAPATAS) | 13d | 2022-05-02 | 2022-05-16 |  | 0d |  |
| 51 | 1.3.1.2 | CORTE DE MATERIAL SUELTO R=150 m3/dia (EQUIPO) | 2d | 2022-05-06 | 2022-05-07 | 12 | 117d | 0d |

| ID | WBS | Task | Duration | Start | Finish | Predecessors | Total slack | Free slack |
| --- | --- | --- | --- | --- | --- | --- | --- | --- |
| 52 | 1.3.2 | **RELLENO** | 10d | 2022-06-23 | 2022-07-04 |  | 67d |  |
| 53 | 1.3.2.1 | RELLENO COMPACTADO MANUAL MATERIAL PROPIO | 7d | 2022-06-23 | 2022-06-30 | 78 | 67d | 0d |
| 54 | 1.3.2.2 | RELLENO COMPACTADO MANUAL MATERIAL DE PRESTAMO (AFIRMADO PREPARADO) | 2d | 2022-07-01 | 2022-07-02 | 53 | 67d | 0d |
| 55 | 1.3.2.3 | RELLENO COMPACTADO MANUAL MATERIAL DE PRESTAMO (HORMIGON) | 1d | 2022-07-04 | 2022-07-04 | 54 | 67d | 0d |
| 56 | 1.3.3 | **CONFORMACION,NIVELACION Y REFINE** | 3d | 2022-05-17 | 2022-05-19 |  | 0d |  |
| 57 | 1.3.3.1 | NIVELACION DE TERRENO Y COMPACTACION | 3d | 2022-05-17 | 2022-05-19 | 50 | 0d |  |
| 58 | 1.3.4 | **MEJORAMIENTO DE TERRENO** | 8d | 2022-05-09 | 2022-05-17 |  | 117d |  |
| 59 | 1.3.4.1 | MEJORAMIENTO DE TERRENO NATURAL e=50cm (COLOCACION DE OVER DE 1" A 6" - CON EQUIPO) | 1d | 2022-05-09 | 2022-05-09 | 51 | 117d | 0d |
| 60 | 1.3.4.2 | MEJORAMIENTO DE TERRENO NATURAL e=50cm (COLOCACION DE HORMIGON - CON EQUIPO) | 1d | 2022-05-10 | 2022-05-10 | 59 | 117d | 0d |
| 61 | 1.3.4.3 | MEJORAMIENTO DE TERRENO NATURAL e=30cm (COLOCACION DE HORMIGÓN - CON EQUIPO) | 1d | 2022-05-11 | 2022-05-11 | 60 | 117d | 0d |
| 62 | 1.3.4.4 | MEJORAMIENTO DE TERRENO NATURAL e=20cm (COLOCACION DE AFIRMADO MEJORADO) | 2d | 2022-05-12 | 2022-05-13 | 61 | 117d | 0d |
| 63 | 1.3.4.5 | MEJORAMIENTO DE TERRENO NATURAL e=10cm (COLOCACION DE AFIRMADO MEJORADO) | 3d | 2022-05-14 | 2022-05-17 | 62 | 117d |  |
| 64 | 1.3.5 | **ACARREO Y ELIMINACION DE MATERIAL** | 13d | 2022-05-02 | 2022-05-16 |  | 118d |  |
| 65 | 1.3.5.1 | ACARREO INTERNO MATERIAL PROCEDENTE DE EXCAVACIONES (Dprom=30m) | 13d | 2022-05-02 | 2022-05-16 | 50SS | 118d |  |
| 66 | 1.3.5.2 | ELIMINACION DE MATERIAL EXCEDENTE CON MAQUINARIA (Dprom=5 km) | 2d | 2022-05-14 | 2022-05-16 | 50FF | 118d |  |
| 67 | 1.4 | **CONCRETO SIMPLE** | 43d | 2022-05-20 | 2022-07-08 |  | 12d |  |
| 68 | 1.4.1 | **SOLADO** | 3d | 2022-05-20 | 2022-05-23 |  | 112d |  |
| 69 | 1.4.1.1 | SOLADO PARA VIGAS DE CIMENTACION e=2", 1:12 C/H | 3d | 2022-05-20 | 2022-05-23 | 57 | 112d |  |
| 70 | 1.4.1.2 | SOLADO PARA ZAPATA e=4", 1:12 C/H | 2d | 2022-05-20 | 2022-05-21 | 57 | 113d |  |
| 71 | 1.4.2 | **FALSO PISO** | 4d | 2022-07-05 | 2022-07-08 |  | 67d |  |
| 72 | 1.4.2.1 | FALSO PISO MEZCLA 1:8 e=4" | 4d | 2022-07-05 | 2022-07-08 | 55 | 67d | 0d |
| 73 | 1.4.3 | **CIMIENTOS** | 7d | 2022-06-03 | 2022-06-10 |  | 0d |  |
| 74 | 1.4.3.1 | CIMIENTOS CORRIDOS 1:10 + 30% P.G. FC=100 Kg/cm2 | 4d | 2022-06-07 | 2022-06-10 | 75 | 0d |  |
| 75 | 1.4.3.2 | CIMIENTOS CORRIDOS; ENCOFRADO Y DESENCOFRADO | 3d | 2022-06-03 | 2022-06-06 | 83 | 0d |  |

| ID | WBS | Task | Duration | Start | Finish | Predecessors | Total slack | Free slack |
| --- | --- | --- | --- | --- | --- | --- | --- | --- |
| 76 | 1.5 | **CONCRETO ARMADO** | 69d | 2022-05-20 | 2022-08-08 |  | 0d |  |
| 77 | 1.5.1 | **SOBRECIMIENTO** | 10d | 2022-06-11 | 2022-06-22 |  | 0d |  |
| 78 | 1.5.1.1 | SOBRECIMIENTOS.-CONCRETO f'c=175 kg/cm2 | 5d | 2022-06-17 | 2022-06-22 | 79SS+5d | 0d |  |
| 79 | 1.5.1.2 | SOBRECIMIENTO, ENCOFRADO Y DESENCOFRADO | 9d | 2022-06-11 | 2022-06-21 | 74 | 0d |  |
| 80 | 1.5.1.3 | SOBRECIMIENTO.-ACERO fy=4200 kg/cm2 | 9d | 2022-06-11 | 2022-06-21 | 79SS | 87d |  |
| 81 | 1.5.2 | **ZAPATAS** | 7d | 2022-05-28 | 2022-06-04 |  | 0d |  |
| 82 | 1.5.2.1 | ZAPATAS.-CONCRETO f'c=210 kg/cm2 | 3d | 2022-06-02 | 2022-06-04 | 83SS+4d | 101d |  |
| 83 | 1.5.2.2 | ZAPATAS.- ENCOFRADO Y DESENCOFRADO | 5d | 2022-05-28 | 2022-06-02 | 87 | 0d |  |
| 84 | 1.5.2.3 | ZAPATAS.-ACERO fy=4200 kg/cm2 | 5d | 2022-05-28 | 2022-06-02 | 83SS | 103d |  |
| 85 | 1.5.2.4 | ZAPATAS.- ENTIBADO H=1.5-2.2m | 5d | 2022-05-28 | 2022-06-02 | 83SS | 103d |  |
| 86 | 1.5.3 | **PLATEA DE CIMENTACIÓN** | 7d | 2022-05-20 | 2022-05-27 |  | 0d |  |
| 87 | 1.5.3.1 | PLATEA DE CIMENTACION.-CONCRETO f'c=210 kg/cm2 | 5d | 2022-05-23 | 2022-05-27 | 88 | 0d |  |
| 88 | 1.5.3.2 | PLATEA DE CIMENTACION.- ENCOFRADO Y DESENCOFRADO | 2d | 2022-05-20 | 2022-05-21 | 57 | 0d |  |
| 89 | 1.5.3.3 | PLATEA DE CIMENTACION.-ACERO fy=4200 kg/cm2 | 2d | 2022-05-20 | 2022-05-21 | 88SS | 113d |  |
| 90 | 1.5.4 | **VIGAS DE CIMENTACION** | 5d | 2022-05-28 | 2022-06-02 |  | 103d |  |
| 91 | 1.5.4.1 | VIGAS DE CIMENTACION.- CONCRETO fc=210kg/cm2 | 1d | 2022-06-02 | 2022-06-02 | 92 | 103d |  |
| 92 | 1.5.4.2 | VIGAS DE CIMENTACION.- ENCOFRADO Y DESENCOFRADO | 4d | 2022-05-28 | 2022-06-01 | 83SS | 103d | 0d |
| 93 | 1.5.4.3 | VIGAS DE CIMENTACION.-ACERO fy=4200 kg/cm2 | 3d | 2022-05-28 | 2022-05-31 | 92SS | 105d |  |
| 94 | 1.5.5 | **COLUMNA** | 13d | 2022-06-23 | 2022-07-07 |  | 0d |  |
| 95 | 1.5.5.1 | COLUMNAS - CONCRETO 210 KG/CM2 | 8d | 2022-06-29 | 2022-07-07 | 96SS+5d | 0d |  |
| 96 | 1.5.5.2 | COLUMNAS.- ENCOFRADO Y DESENCOFRADO | 11d | 2022-06-23 | 2022-07-05 | 78 | 0d |  |
| 97 | 1.5.5.3 | COLUMNAS.-ACERO fy=4200 kg/cm2 | 11d | 2022-06-23 | 2022-07-05 | 96SS | 75d |  |
| 98 | 1.5.6 | **VIGAS** | 27d | 2022-07-08 | 2022-08-08 |  | 0d |  |
| 99 | 1.5.6.1 | VIGAS - CONCRETO 210Kg/cm2 | 4d | 2022-08-04 | 2022-08-08 | 103 | 46d |  |
| 100 | 1.5.6.2 | VIGAS.- ENCOFRADO Y DESENCOFRADO | 9d | 2022-07-08 | 2022-07-18 | 95 | 0d |  |
| 101 | 1.5.6.3 | VIGAS.-ACERO fy=4200 kg/cm2 | 9d | 2022-07-08 | 2022-07-18 | 100SS | 64d |  |

| ID | WBS | Task | Duration | Start | Finish | Predecessors | Total slack | Free slack |
| --- | --- | --- | --- | --- | --- | --- | --- | --- |
| 102 | 1.5.7 | **LOSAS ALIGERADAS** | 14d | 2022-07-19 | 2022-08-03 |  | 0d |  |
| 103 | 1.5.7.1 | LOSA ALIGERADA - CONCRETO 210 kg/cm2 | 3d | 2022-08-01 | 2022-08-03 | 104 | 0d |  |
| 104 | 1.5.7.2 | LOSA ALIGERADA.- ENCOFRADO Y DESENCOFRADO | 11d | 2022-07-19 | 2022-07-30 | 100 | 0d |  |
| 105 | 1.5.7.3 | LOSA ALIGERADA.-ACERO fy=4200 kg/cm2 | 11d | 2022-07-19 | 2022-07-30 | 104SS | 53d |  |
| 106 | 1.5.7.4 | LOSA ALIGERADA.- LADR. HUECO 15X30X30 | 3d | 2022-08-01 | 2022-08-03 | 104 | 46d | 0d |
| 107 | 1.5.8 | **ESCALERAS** | 5d | 2022-07-08 | 2022-07-13 |  | 68d |  |
| 108 | 1.5.8.1 | ESCALERAS.- CONCRETO fc=210 kg/cm2 | 1d | 2022-07-13 | 2022-07-13 | 109 | 68d |  |
| 109 | 1.5.8.2 | ESCALERAS.- ENCOFRADO Y DESENCOFRADO | 4d | 2022-07-08 | 2022-07-12 | 95 | 68d | 0d |
| 110 | 1.5.8.3 | ESCALERAS.- ACERO fy=4200 kg/cm2 | 3d | 2022-07-08 | 2022-07-11 | 109SS | 70d |  |
| 111 | 1.5.9 | **LOSA MACISA** | 15d | 2022-07-19 | 2022-08-04 |  | 49d |  |
| 112 | 1.5.9.1 | LOSA MACISA.-CONCRETO f'c=210 kg/cm2 | 1d | 2022-08-04 | 2022-08-04 | 103 | 43d | 0d |
| 113 | 1.5.9.2 | LOSA MACISA.- ENCOFRADO Y DESENCOFRADO | 2d | 2022-07-19 | 2022-07-20 | 104SS | 60d | 0d |
| 114 | 1.5.9.3 | LOSA MACISA.-ACERO fy=4200 kg/cm2 | 4d | 2022-07-19 | 2022-07-22 | 113SS | 60d |  |
| 115 | 1.5.10 | **CUNETAS CON REJILLA** | 5d | 2022-06-04 | 2022-06-09 |  | 89d |  |
| 116 | 1.5.10.1 | CUNETAS.-CONCRETO f'c=175 kg/cm2 | 1d | 2022-06-09 | 2022-06-09 | 117 | 89d | 0d |
| 117 | 1.5.10.2 | CUNETAS.- ENCOFRADO Y DESENCOFRADO | 4d | 2022-06-04 | 2022-06-08 | 164 | 89d | 0d |
| 118 | 1.5.10.3 | CUNETAS.-ACERO fy=4200 kg/cm2 | 3d | 2022-06-04 | 2022-06-07 | 117SS | 99d |  |
| 119 | 1.5.11 | **CISTERNA** | 3d | 2022-05-28 | 2022-05-31 |  | 96d |  |
| 120 | 1.5.11.1 | CISTERNA.-CONCRETO f'c=210 kg/cm2 | 1d | 2022-05-31 | 2022-05-31 | 121 | 96d | 0d |
| 121 | 1.5.11.2 | CISTERNA.- ENCOFRADO Y DESENCOFRADO | 2d | 2022-05-28 | 2022-05-30 | 222 | 96d | 0d |
| 122 | 1.5.11.3 | CISTERNA.-ACERO fy=4200 kg/cm2 | 3d | 2022-05-28 | 2022-05-31 | 121SS | 105d |  |
| 123 | 1.5.12 | **BANCAS DE CONCRETO** | 2d | 2022-06-04 | 2022-06-06 |  | 100d |  |
| 124 | 1.5.12.1 | BANCAS.-CONCRETO f'c=175 kg/cm2 | 1d | 2022-06-06 | 2022-06-06 | 125 | 100d |  |
| 125 | 1.5.12.2 | BANCA.- ENCOFRADO Y DESENCOFRADO | 1d | 2022-06-04 | 2022-06-04 | 164 | 100d | 0d |
| 126 | 1.5.12.3 | BANCAS.-ACERO fy=4200 kg/cm2 | 1d | 2022-06-04 | 2022-06-04 | 125SS | 101d |  |

| ID | WBS | Task | Duration | Start | Finish | Predecessors | Total slack | Free slack |
| --- | --- | --- | --- | --- | --- | --- | --- | --- |
| 127 | 1.6 | **ESTRUCTURAS METALICAS** | 22d | 2022-07-08 | 2022-08-02 |  | 51d |  |
| 128 | 1.6.1 | TIJERAL T-1(HABILITACION Y MONTAJE) | 5d | 2022-07-08 | 2022-07-13 | 95 | 51d | 0d |
| 129 | 1.6.2 | VIGUETA METALICA VG1 (HABILITACIÓN Y MONTAJE) | 6d | 2022-07-14 | 2022-07-20 | 128 | 51d | 0d |
| 130 | 1.6.3 | TEMPLADOR Y CRUZ DE SAN ANDRES | 2d | 2022-07-21 | 2022-07-22 | 129 | 51d | 0d |
| 131 | 1.6.4 | APOYOS METALICOS FIJO Y MOVIL | 3d | 2022-07-08 | 2022-07-11 | 128SS | 70d |  |
| 132 | 1.6.5 | CANALETA FG 1.6MM | 2d | 2022-08-01 | 2022-08-02 | 133 | 51d |  |
| 133 | 1.6.6 | COBERTURA LIVIANA | 7d | 2022-07-23 | 2022-07-30 | 130 | 51d | 0d |
| 134 | 2 | **ARQUITECTURA** | 131d | 2022-05-02 | 2022-09-30 |  | 0d |  |
| 135 | 2.1 | **MUROS Y TABIQUES DE ALBAÑILERIA** | 76d | 2022-06-23 | 2022-09-19 |  | 10d |  |
| 136 | 2.1.1 | MURO DE LADRILLO KK TIPO IV SOGA M : 1:1:4 e=1.5cm | 14d | 2022-07-04 | 2022-07-19 | 137 | 59d | 0d |
| 137 | 2.1.2 | MURO DE LADRILLO KK TIPO IV CABEZA M : 1:1:4 e=1.5cm | 9d | 2022-06-23 | 2022-07-02 | 78 | 59d | 0d |
| 138 | 2.1.3 | MURO DE DRYWALL DOBLE ESTRUCTURA e= 1.5cm | 2d | 2022-09-17 | 2022-09-19 | 155 | 10d |  |
| 139 | 2.1.4 | FIERRO REFUERZO HORIZONTAL EN MUROS | 2d | 2022-06-23 | 2022-06-24 | 137SS | 84d |  |
| 140 | 2.2 | **REVOQUES Y REVESTIMIENTOS** | 85d | 2022-06-01 | 2022-09-07 |  | 20d |  |
| 141 | 2.2.1 | TARRAJEO DEL TIPO RAYADO O PRIMARIO CON MORTERO 1:5 | 8d | 2022-08-04 | 2022-08-12 | 142SS | 24d | 0d |
| 142 | 2.2.2 | TARRAJEO EN MUROS INTERIORES | 9d | 2022-08-04 | 2022-08-13 | 103 | 0d |  |
| 143 | 2.2.3 | TARRAJEO EN MUROS EXTERIORES | 9d | 2022-08-29 | 2022-09-07 | 150 | 8d | 0d |
| 144 | 2.2.4 | TARRAJEO DE COLUMNAS | 12d | 2022-08-04 | 2022-08-17 | 142SS | 31d | 0d |
| 145 | 2.2.5 | TARRAJEO DE VIGAS | 7d | 2022-08-15 | 2022-08-22 | 142 | 34d |  |
| 146 | 2.2.6 | TARRAJEO CON IMPERMEABILIZANTE | 5d | 2022-06-01 | 2022-06-06 | 120 | 96d | 0d |
| 147 | 2.2.7 | VESTIDURA DE DERRAMES (1:5) | 10d | 2022-08-15 | 2022-08-25 | 142 | 31d |  |
| 148 | 2.2.8 | BRUÑAS SEGÚN DETALLE | 5d | 2022-09-02 | 2022-09-07 | 143FF | 20d |  |
| 149 | 2.3 | **CIELORRASOS** | 12d | 2022-08-15 | 2022-08-27 |  | 0d |  |
| 150 | 2.3.1 | CIELORRASO CON MEZCLA C:A 1:5 | 12d | 2022-08-15 | 2022-08-27 | 142 | 0d |  |

| ID | WBS | Task | Duration | Start | Finish | Predecessors | Total slack | Free slack |
| --- | --- | --- | --- | --- | --- | --- | --- | --- |
| 151 | 2.4 | **PISOS Y PAVIMENTOS** | 103d | 2022-05-20 | 2022-09-16 |  | 12d |  |
| 152 | 2.4.1 | **CONTRAPISOS** | 4d | 2022-07-09 | 2022-07-13 |  | 67d |  |
| 153 | 2.4.1.1 | CONTRAPISO DE 40 mm | 4d | 2022-07-09 | 2022-07-13 | 72 | 67d | 0d |
| 154 | 2.4.2 | **PISOS** | 103d | 2022-05-20 | 2022-09-16 |  | 12d |  |
| 155 | 2.4.2.1 | PISO PORCELANATO 60 x 60 MODELO DOMINE MATE BLANCO- ALTO TRANSITO | 17d | 2022-08-29 | 2022-09-16 | 150 | 0d |  |
| 156 | 2.4.2.2 | PISO CERAMICO 30 x 30 | 1d | 2022-08-29 | 2022-08-29 | 155SS | 28d | 0d |
| 157 | 2.4.2.3 | PISO CERAMICO 45 x 45 ALTO TRÁNSITO | 1d | 2022-08-29 | 2022-08-29 | 156SS | 28d |  |
| 158 | 2.4.2.4 | PISO DE CONCRETO EN PATIOS f'c=175kg/cm2; e=15cm FROTACHADO | 2d | 2022-05-21 | 2022-05-23 | 159 | 89d | 0d |
| 159 | 2.4.2.5 | PATIOS.- ENCOFRADO Y DESENCOFRADO | 1d | 2022-05-20 | 2022-05-20 | 57 | 89d | 0d |
| 160 | 2.4.3 | **SARDINELES** | 3d | 2022-05-24 | 2022-05-26 |  | 89d |  |
| 161 | 2.4.3.1 | SARDINEL.-CONCRETO f'c=175 kg/cm2 (INC. EXCAVACION) | 1d | 2022-05-26 | 2022-05-26 | 162 | 89d | 0d |
| 162 | 2.4.3.2 | SARDINEL.- ENCOFRADO Y DESENCOFRADO | 2d | 2022-05-24 | 2022-05-25 | 158 | 89d | 0d |
| 163 | 2.4.4 | **VEREDAS Y RAMPAS** | 8d | 2022-05-27 | 2022-06-04 |  | 89d |  |
| 164 | 2.4.4.1 | VEREDAS e=4" DE CONCRETO f'c=175kg/cm2 ACABADO FROTACHADO Y BRUÑADO | 4d | 2022-05-31 | 2022-06-03 | 166 | 89d | 0d |
| 165 | 2.4.4.2 | RAMPAS e=4" DE CONCRETO f'c=175kg/cm2 ACABADO FROTACHADO Y BRUÑADO | 1d | 2022-06-04 | 2022-06-04 | 164 | 101d | 0d |
| 166 | 2.4.4.3 | VEREDAS Y RAMPAS.- ENCOFRADO Y DESENCOFRADO | 3d | 2022-05-27 | 2022-05-30 | 161 | 89d | 0d |
| 167 | 2.5 | **ZOCALOS Y CONTRAZÓCALOS** | 42d | 2022-08-13 | 2022-09-30 |  | 0d |  |
| 168 | 2.5.1 | **ZOCALOS** | 7d | 2022-08-13 | 2022-08-20 |  | 24d |  |
| 169 | 2.5.1.1 | ZOCALO PORCELANATO 60 x 60 MODELO POTENSA BLANCO PERLA MATE- ALTO TRANSITO | 7d | 2022-08-13 | 2022-08-20 | 141 | 24d | 0d |
| 170 | 2.5.2 | **CONTRAZOCALOS** | 20d | 2022-09-08 | 2022-09-30 |  | 0d |  |
| 171 | 2.5.2.1 | CONTRAZOCALO DE PORCELANATO 50X60 MODELO POTENSA BLANCO PERLA MATE-ALTO TRANSITO | 12d | 2022-09-08 | 2022-09-21 | 143 | 8d |  |
| 172 | 2.5.2.2 | CONTRAZOCALO DE PORCELANATO 20X60 MODELO POTENSA BLANCO PERLA MATE-ALTO TRANSITO | 7d | 2022-09-17 | 2022-09-24 | 155 | 0d |  |
| 173 | 2.5.2.3 | CONTRAZOCALO PORCELANATO 10 x 60 MODELO POTENSA BLANCO PERLA MATE- ALTO TRANSITO | 5d | 2022-09-26 | 2022-09-30 | 172 | 0d |  |
| 174 | 2.6 | **COBERTURAS** | 15d | 2022-08-04 | 2022-08-20 |  | 32d |  |
| 175 | 2.6.1 | COBERTURA CON PLANCHA CALAMINON TAT 1060 TERMO-AISLANTE e=25mm (INC. ESTRUCTURA DE SOPORTE METALICA) | 11d | 2022-08-09 | 2022-08-20 | 176 | 32d | 0d |
| 176 | 2.6.2 | IMPERMEABILIZANTE DE TECHOS CON PINTURA ASFALTICA | 4d | 2022-08-04 | 2022-08-08 | 103 | 32d | 0d |

| ID | WBS | Task | Duration | Start | Finish | Predecessors | Total slack | Free slack |
| --- | --- | --- | --- | --- | --- | --- | --- | --- |
| 177 | 2.7 | **CARPINTERIA DE MADERA** | 9d | 2022-09-14 | 2022-09-23 |  | 3d |  |
| 178 | 2.7.1 | PUERTA MACHIEMBRADA | 5d | 2022-09-14 | 2022-09-19 | 208 | 3d | 0d |
| 179 | 2.7.2 | PUERTA CONTRAPLACADA 40 mm CON TRIPLAY 6 mm INCLUYE MARCO CEDRO 2"x4" | 4d | 2022-09-20 | 2022-09-23 | 178 | 3d | 0d |
| 180 | 2.7.3 | PIZARRA ACRILICA | 4d | 2022-09-14 | 2022-09-17 | 208 | 11d |  |
| 181 | 2.8 | **CARPINTERIA METALICA Y HERRERÍA** | 104d | 2022-05-24 | 2022-09-21 |  | 8d |  |
| 182 | 2.8.1 | CANTONERA DE FIERRO EN ESCALERA | 3d | 2022-09-17 | 2022-09-20 | 155 | 8d | 0d |
| 183 | 2.8.2 | PUERTAS DE INGRESOS PRINCIPALES | 7d | 2022-08-18 | 2022-08-25 | 144 | 31d |  |
| 184 | 2.8.3 | ASTA DE BANDERA | 1d | 2022-05-24 | 2022-05-24 | 158 | 111d |  |
| 185 | 2.8.4 | BARANDA METALICA EN ESCALERA | 1d | 2022-09-21 | 2022-09-21 | 182 | 8d |  |
| 186 | 2.8.5 | REJILLA METALICA PARA CUNETA DE 1"X1"X1/8" (INCLUYE COLOCACION) | 8d | 2022-06-10 | 2022-06-18 | 116 | 89d |  |
| 187 | 2.8.6 | SUMINISTRO E INSTALACION DE ENCUENTRO METALICO ENTRE SOBRETECHO Y PARAPETO | 7d | 2022-08-04 | 2022-08-11 | 176SS | 43d |  |
| 188 | 2.8.7 | SUMINISTRO E INSTALACION DE CANALETA DE EVACUACION PLUVIAL 610 mm | 3d | 2022-08-22 | 2022-08-24 | 175 | 32d |  |
| 189 | 2.8.8 | BATERIAS ECOLOGICAS DE TRES TACHOS | 2d | 2022-06-04 | 2022-06-06 | 164 | 100d |  |
| 190 | 2.8.9 | ESCALERA DE GATO DE FIERRO GALVANIZADO | 2d | 2022-06-07 | 2022-06-08 | 146 | 98d |  |
| 191 | 2.8.10 | ESCALERA DE ALUMINIO EN CISTERNA | 1d | 2022-06-07 | 2022-06-07 | 146 | 99d |  |
| 192 | 2.8.11 | PUERTA DE CASETA DE ELECTROBOMBA | 1d | 2022-06-07 | 2022-06-07 | 146 | 98d | 0d |
| 193 | 2.8.12 | DIVISIONES METÁLICAS EN BAÑOS | 1d | 2022-09-17 | 2022-09-17 | 155 | 9d | 0d |
| 194 | 2.8.13 | PUERTAS VAIVEN METÁLICAS EN BAÑOS | 1d | 2022-09-19 | 2022-09-19 | 193 | 9d | 0d |
| 195 | 2.8.14 | TUBOS METÁLICOS EN CERCO PERIMÉTRICO | 4d | 2022-08-18 | 2022-08-22 | 144 | 32d | 0d |
| 196 | 2.9 | **VENTANAS DE ALUMINIO CON PROTECTOR, CRISTAL Y VIDRIOS** | 12d | 2022-09-14 | 2022-09-27 |  | 3d |  |
| 197 | 2.9.1 | SUMINISTRO E INSTALACION DE VENTANA DE ALUMINIO CON CRISTAL CRUDO DE 6 mm INCOLORO + LAMINA DE SEGURIDAD DE 4 MICRAS Y PROTECTOR DE SEGURIDAD | 12d | 2022-09-14 | 2022-09-27 | 208 | 3d | 0d |
| 198 | 2.9.2 | SUMINISTRO E INSTALACION DE PROTECTORES DE SEGURIDAD DE ALUMINIO | 8d | 2022-09-14 | 2022-09-22 | 197SS | 7d |  |
| 199 | 2.10 | **CERRAJERIA** | 95d | 2022-06-08 | 2022-09-26 |  | 4d |  |
| 200 | 2.10.1 | BISAGRA ALUMINIZADA DE 4" PESADA EN PUERTAS | 5d | 2022-09-20 | 2022-09-24 | 178 | 5d |  |
| 201 | 2.10.2 | BISAGRA ALUMINIZADA DE 3" PESADA EN PUERTAS | 2d | 2022-09-24 | 2022-09-26 | 179 | 4d |  |
| 202 | 2.10.3 | CERRADURA TRES GOLPES CON TIRADOR EN PUERTAS | 2d | 2022-09-24 | 2022-09-26 | 179 | 4d |  |
| 203 | 2.10.4 | CHAPA DE POMO CON PESTILLO EN PUERTA | 1d | 2022-09-24 | 2022-09-24 | 179 | 5d |  |
| 204 | 2.10.5 | PICAPORTE EN PUERTAS DE SS.HH | 1d | 2022-09-20 | 2022-09-20 | 194 | 9d |  |
| 205 | 2.10.6 | CANDADO DE 60mm | 1d | 2022-06-08 | 2022-06-08 | 192 | 98d |  |

| ID | WBS | Task | Duration | Start | Finish | Predecessors | Total slack | Free slack |
| --- | --- | --- | --- | --- | --- | --- | --- | --- |
| 206 | 2.11 | **PINTURA** | 31d | 2022-08-23 | 2022-09-27 |  | 3d |  |
| 207 | 2.11.1 | PINTURA LATEX 2 MANOS EN MUROS Y COLUMNAS | 9d | 2022-08-29 | 2022-09-07 | 150 | 1d | 0d |
| 208 | 2.11.2 | PINTURA LATEX 2 MANOS EN CIELO RASO Y VIGAS | 5d | 2022-09-08 | 2022-09-13 | 207 | 1d | 0d |
| 209 | 2.11.3 | PINTURA ANTICORROSIVA Y ESMALTE 2 MANOS DE CARPINTERIA METALICA | 2d | 2022-08-23 | 2022-08-24 | 195 | 32d |  |
| 210 | 2.11.4 | PINTURA EN PUERTAS DE MADERA | 3d | 2022-09-24 | 2022-09-27 | 179 | 3d |  |
| 211 | 2.12 | **JUNTAS** | 86d | 2022-05-24 | 2022-08-31 |  | 26d |  |
| 212 | 2.12.1 | JUNTA DE DILATACION EN PISOS CON TECNOPORT DE e= 3/8" RELLENO CON POLIURETANO | 2d | 2022-05-24 | 2022-05-25 | 158 | 110d |  |
| 213 | 2.12.2 | JUNTAS DE DILATACION CON ESPUMA PLÁSTICA RELLENO CON POLIURETANO | 3d | 2022-08-29 | 2022-08-31 | 143SS | 26d |  |
| 214 | 2.12.3 | JUNTAS ASFALTICAS e=1" | 2d | 2022-06-04 | 2022-06-06 | 164 | 100d |  |
| 215 | 2.13 | **VARIOS** | 30d | 2022-05-02 | 2022-06-04 |  | 101d |  |
| 216 | 2.13.1 | CURADO CON CURADOR QUIMICO PARA CONCRETO | 4d | 2022-06-01 | 2022-06-04 | 165FF | 101d |  |
| 217 | 2.13.2 | SUMINISTRO E INSTALACION DE STICKER PARA SEÑALITICA DE SEGURIDAD | 2d | 2022-05-02 | 2022-05-03 |  | 129d |  |
| 218 | 2.13.3 | SUMINISTRO E INSTALACION DE EXTINTOR DE POLVO QUIMICO SECO | 1d | 2022-05-02 | 2022-05-02 |  | 130d |  |
| 219 | 3 | **INSTALACIONES SANITARIAS** | 101d | 2022-05-20 | 2022-09-14 |  | 14d |  |
| 220 | 3.1 | **MOVIMIENTO DE TIERRAS** | 27d | 2022-05-20 | 2022-06-20 |  | 88d |  |
| 221 | 3.1.1 | EXCAVACION DE ZANJAS PARA H=0.80m, PARA TUBERIA DE 160 Y 200 mm | 2d | 2022-05-20 | 2022-05-21 | 57 | 88d | 0d |
| 222 | 3.1.2 | EXCAVACION DE ZANJAS MANUAL H<=3.00m | 5d | 2022-05-23 | 2022-05-27 | 221 | 96d | 0d |
| 223 | 3.1.3 | RELLENO C/ARENA HASTA e=0.20m LA CLAVE PARA TUBO DE 160 Y 200 mm | 5d | 2022-06-09 | 2022-06-14 | 269 | 88d | 0d |
| 224 | 3.1.4 | RELLENO Y COMPACTACION DE ZANJAS C/ MATERIAL PROPIO CON EQUIPO H=0.8m | 5d | 2022-06-15 | 2022-06-20 | 223 | 88d |  |
| 225 | 3.1.5 | REFINE, NIVELACION DE ZANJAS P/TUBO DE 160 Y 200 mm | 2d | 2022-05-23 | 2022-05-24 | 221 | 88d | 0d |
| 226 | 3.1.6 | CAMA DE ARENA GRUESA e=0.10m PARA TUBO DE 160 Y 200 mm | 2d | 2022-05-25 | 2022-05-26 | 225 | 109d |  |
| 227 | 3.2 | **SISTEMA DE AGUA POTABLE EXTERIOR** | 63d | 2022-05-25 | 2022-08-05 |  | 48d |  |
| 228 | 3.2.1 | TUBERIA PVC-SAP 2" CLASE 10 | 2d | 2022-05-25 | 2022-05-26 | 225 | 88d | 0d |
| 229 | 3.2.2 | TUBERIA PVC-SAP 1" CLASE 10 | 1d | 2022-05-27 | 2022-05-27 | 228 | 88d | 0d |
| 230 | 3.2.3 | TUBERIA PVC-SAP 3/4" CLASE 10 | 1d | 2022-05-28 | 2022-05-28 | 229 | 88d | 0d |
| 231 | 3.2.4 | VALVULA TIPO BOLA 1 1/2" | 1d | 2022-05-31 | 2022-05-31 | 232 | 105d |  |
| 232 | 3.2.5 | CAJA PREFABRICADA P/VALVULAS | 1d | 2022-05-30 | 2022-05-30 | 230 | 105d | 0d |
| 233 | 3.2.6 | SUMINISTRO E INSTALACION DE TANQUE DE AGUA DE POLIETILENO (2,500L) | 1d | 2022-08-05 | 2022-08-05 | 112 | 43d | 0d |

| ID | WBS | Task | Duration | Start | Finish | Predecessors | Total slack | Free slack |
| --- | --- | --- | --- | --- | --- | --- | --- | --- |
| 234 | 3.3 | **SISTEMA DE RIEGO** | 1d | 2022-05-28 | 2022-05-28 |  | 107d |  |
| 235 | 3.3.1 | LLAVE DE RIEGO C/GRIFO DE ½" EN CAJUELA CONCRETO F'c 140 S/D | 1d | 2022-05-28 | 2022-05-28 | 229 | 107d |  |
| 236 | 3.4 | **SISTEMA DE DESAGUE EXTERIOR** | 4d | 2022-05-25 | 2022-05-28 |  | 99d |  |
| 237 | 3.4.1 | TUBERIA DE PVC SAL 4" | 1d | 2022-05-25 | 2022-05-25 | 225 | 99d | 0d |
| 238 | 3.4.2 | SUMINISTRO E INSTALACION DE TUBERIA PVC 160mm ISO 4435 S-20 | 1d | 2022-05-26 | 2022-05-26 | 237 | 109d |  |
| 239 | 3.4.3 | CAJA DE REGISTRO PREFABRICADA DE 12" X 24" CON TAPA DE CONCRETO | 4d | 2022-05-25 | 2022-05-28 | 225 | 107d |  |
| 240 | 3.4.4 | CAJA DE REGISTRO DE ALBAÑILERIA DE 24" X 24" CON TAPA DE CONCRETO | 1d | 2022-05-25 | 2022-05-25 | 225 | 110d |  |
| 241 | 3.4.5 | SUMINISTRO E INSTALACION DE BIODIGESTOR | 1d | 2022-05-28 | 2022-05-28 | 222 | 107d |  |
| 242 | 3.5 | **PRUEBA HIDRAULICA DE CISTERNA, TANQUE Y SISTEMA DE BOMBEO** | 2d | 2022-06-07 | 2022-06-08 |  | 98d |  |
| 243 | 3.5.1 | PRUEBA HIDRAULICA DE CISTERNA Y EQUIPO DE BOMBEO | 2d | 2022-06-07 | 2022-06-08 | 146 | 98d |  |
| 244 | 3.6 | **APARATOS SANITARIOS Y ACCESORIOS** | 54d | 2022-07-14 | 2022-09-14 |  | 14d |  |
| 245 | 3.6.1 | INODORO TANQUE BAJO DE LOSA INCLUYE ACCESORIOS | 3d | 2022-08-22 | 2022-08-24 | 169 | 24d | 0d |
| 246 | 3.6.2 | URINARIOS DE LOZA DE PICO | 1d | 2022-08-25 | 2022-08-25 | 245 | 24d | 0d |
| 247 | 3.6.3 | LAVATORIO DE LOZA BLANCA | 3d | 2022-08-26 | 2022-08-29 | 246 | 24d | 0d |
| 248 | 3.6.4 | DISPENSADOR DE JABON LIQUIDO | 1d | 2022-08-30 | 2022-08-30 | 247 | 24d | 0d |
| 249 | 3.6.5 | PAPELERA DE CERAMICA | 1d | 2022-08-31 | 2022-08-31 | 248 | 24d | 0d |
| 250 | 3.6.6 | TRAMPA DE GRASA TIPO HEVEX MODELO IG-20 | 1d | 2022-07-14 | 2022-07-14 | 153 | 67d |  |
| 251 | 3.6.7 | ESPEJO BISELADO | 1d | 2022-09-14 | 2022-09-14 | 208 | 14d |  |
| 252 | 3.6.8 | PAPELERA PLASTICA | 1d | 2022-09-01 | 2022-09-01 | 249 | 24d | 0d |
| 253 | 3.6.9 | LAVADERO DE ACERO INOXIDABLE | 1d | 2022-09-02 | 2022-09-02 | 252 | 24d |  |
| 254 | 3.6.10 | MESA CORRIDA DE CONCRETO REVEST. C/CERÁMICO | 4d | 2022-07-20 | 2022-07-23 | 136 | 59d |  |
| 255 | 3.7 | **INSTALACIONES SANITARIAS DE DESAGUE** | 11d | 2022-05-26 | 2022-06-07 |  | 99d |  |
| 256 | 3.7.1 | SALIDA DE DESAGUE EN PVC | 5d | 2022-05-26 | 2022-05-31 | 237 | 102d | 0d |
| 257 | 3.7.2 | SALIDA PARA VENTILACION | 3d | 2022-06-01 | 2022-06-03 | 256 | 102d |  |
| 258 | 3.7.3 | TUBERIA PVC-SAL 2" | 4d | 2022-05-30 | 2022-06-02 | 259 | 99d | 0d |
| 259 | 3.7.4 | TUBERIA PVC-SAL 4" | 3d | 2022-05-26 | 2022-05-28 | 237 | 99d | 0d |
| 260 | 3.7.5 | REGISTROS DE BRONCE DE 4" | 2d | 2022-05-30 | 2022-05-31 | 259 | 105d |  |
| 261 | 3.7.6 | REGISTROS DE BRONCE DE 2" | 2d | 2022-06-03 | 2022-06-04 | 258 | 99d | 0d |
| 262 | 3.7.7 | PRUEBA HIDRAULICA Y ESCORRENTIA TUB. DESAGUE | 2d | 2022-06-06 | 2022-06-07 | 261 | 99d |  |

| ID | WBS | Task | Duration | Start | Finish | Predecessors | Total slack | Free slack |
| --- | --- | --- | --- | --- | --- | --- | --- | --- |
| 263 | 3.8 | **INSTALACIONES SANITARIAS DE AGUA** | 9d | 2022-05-30 | 2022-06-08 |  | 88d |  |
| 264 | 3.8.1 | SALIDA DE AGUA FRIA.- PVC | 5d | 2022-05-30 | 2022-06-03 | 230 | 88d | 0d |
| 265 | 3.8.2 | TUBERIA PVC CLASE 10 - 1/2" ROSCADA | 1d | 2022-06-04 | 2022-06-04 | 264 | 88d | 0d |
| 266 | 3.8.3 | TUBERIA PVC CLASE 10 - 3/4" ROSCADA | 1d | 2022-06-06 | 2022-06-06 | 265 | 88d | 0d |
| 267 | 3.8.4 | VALVULA DE COMPUERTA DE BRONCE 3/4" | 1d | 2022-06-08 | 2022-06-08 | 268 | 98d |  |
| 268 | 3.8.5 | CAJA DE MADERA PARA VALVULA | 1d | 2022-06-07 | 2022-06-07 | 266 | 88d | 0d |
| 269 | 3.8.6 | PRUEBA HIDRAULICA EN TUBERIA DE AGUA | 1d | 2022-06-08 | 2022-06-08 | 268 | 88d | 0d |
| 270 | 3.9 | **TUBERIAS Y ACCESORIOS TANQUE ELEVADO** | 57d | 2022-06-07 | 2022-08-11 |  | 43d |  |
| 271 | 3.9.1 | TUBERIA FIERRO GALVANIZADO 3" | 1d | 2022-08-06 | 2022-08-06 | 233 | 43d | 0d |
| 272 | 3.9.2 | TUBERIA DE PVC SAP 2" CLASE 10 | 1d | 2022-08-08 | 2022-08-08 | 271 | 43d | 0d |
| 273 | 3.9.3 | TUBERIA DE PVC SAP 2 1/2" CLASE 10 | 1d | 2022-08-09 | 2022-08-09 | 272 | 43d | 0d |
| 274 | 3.9.4 | TUBERIA FIERRO GALVANIZADO 2" | 1d | 2022-08-08 | 2022-08-08 | 272SS | 46d |  |
| 275 | 3.9.5 | TUBERIA FIERRO GALVANIZADO 1 1/2" | 1d | 2022-08-10 | 2022-08-10 | 273 | 43d | 0d |
| 276 | 3.9.6 | TUBERIA PVC CLASE 10 - 1/2" ROSCADA | 1d | 2022-08-11 | 2022-08-11 | 275 | 43d | 0d |
| 277 | 3.9.7 | VALVULA CHECK 2" | 1d | 2022-08-08 | 2022-08-08 | 272SS | 46d |  |
| 278 | 3.9.8 | VALVULA CHECK 1 1/2" | 1d | 2022-08-10 | 2022-08-10 | 275SS | 44d |  |
| 279 | 3.9.9 | VALVULA DE COMPUERTA DE BRONCE 2" | 1d | 2022-08-08 | 2022-08-08 | 272SS | 46d |  |
| 280 | 3.9.10 | VALVULA DE COMPUERTA DE BRONCE 1 1/2" | 1d | 2022-08-10 | 2022-08-10 | 275SS | 44d |  |
| 281 | 3.9.11 | VALVULA DE COMPUERTA DE BRONCE 1/2" | 1d | 2022-08-11 | 2022-08-11 | 276SS | 43d |  |
| 282 | 3.9.12 | VALVULA FLOTADORA 1 1/2" | 1d | 2022-08-10 | 2022-08-10 | 275SS | 43d | 0d |
| 283 | 3.9.13 | VALVULA FLOTADORA 3/4" | 1d | 2022-08-11 | 2022-08-11 | 282 | 43d |  |
| 284 | 3.9.14 | CAJA BAYPAS DE CONCRETO | 1d | 2022-08-06 | 2022-08-06 | 271SS | 47d |  |
| 285 | 3.9.15 | CAJA DE REBOSE CON REJILLA METALICA | 1d | 2022-08-06 | 2022-08-06 | 271SS | 47d |  |
| 286 | 3.9.16 | SUMINISTRO E INSTALACION DE EQUIPO DE BOMBEO | 1d | 2022-08-06 | 2022-08-06 | 271SS | 47d |  |
| 287 | 3.9.17 | TAPA DE FIERRO EN CISTERNA | 1d | 2022-06-07 | 2022-06-07 | 146 | 96d | 0d |
| 288 | 3.9.18 | REBOSE DE TANQUE ALTO FIERRO GALVAN. 2" | 1d | 2022-06-08 | 2022-06-08 | 287 | 98d |  |
| 289 | 3.9.19 | REBOSE DE CISTERNA DE FIERRO GALVANIZADA 4" | 1d | 2022-06-08 | 2022-06-08 | 287 | 96d | 0d |
| 290 | 3.9.20 | ABRAZADERA DE FIJACION DE TUBO | 1d | 2022-06-09 | 2022-06-09 | 289 | 96d | 0d |
| 291 | 3.9.21 | ROMPE AGUA | 1d | 2022-06-10 | 2022-06-10 | 290 | 96d |  |

| ID | WBS | Task | Duration | Start | Finish | Predecessors | Total slack | Free slack |
| --- | --- | --- | --- | --- | --- | --- | --- | --- |
| 292 | 3.10 | **SISTEMA DE DRENAJE PLUVIAL** | 38d | 2022-05-27 | 2022-07-09 |  | 71d |  |
| 293 | 3.10.1 | TUBERIA DE BAJADA Y RED PVC SAP 110 mm | 2d | 2022-07-08 | 2022-07-09 | 95 | 71d |  |
| 294 | 3.10.2 | SUMINISTRO E INSTALACION TUBERIA PVC 200mm ISO 4435 S-20 | 1d | 2022-05-27 | 2022-05-27 | 166SS | 108d | 0d |
| 295 | 3.10.3 | CAJA DE REGISTRO PREFABRICADA DE 18" X 24" CON TAPA DE CONCRETO | 1d | 2022-05-27 | 2022-05-27 | 294SS | 108d |  |
| 296 | 3.11 | **RECONEXION A LAS REDES EXISTENTES** | 1d | 2022-05-25 | 2022-05-25 |  | 110d |  |
| 297 | 3.11.1 | EMPALME A RED EXISTENTE, AGUA | 1d | 2022-05-25 | 2022-05-25 | 228SS | 110d |  |
| 298 | 4 | **INSTALACIONES ELECTRICAS** | 130d | 2022-05-02 | 2022-09-29 |  | 1d |  |
| 299 | 4.1 | **MOVIMIENTO DE TIERRAS** | 69d | 2022-05-20 | 2022-08-08 |  | 46d |  |
| 300 | 4.1.1 | EXCAVACION MANUAL DE ZANJAS PARA CABLE ELECTRICO DE 100 x 100 cm | 4d | 2022-05-20 | 2022-05-24 | 57 | 103d | 0d |
| 301 | 4.1.2 | REFINE, NIVELACION DE ZANJAS INCLUYE CAMA DE 100 CM | 1d | 2022-05-25 | 2022-05-25 | 300 | 110d |  |
| 302 | 4.1.3 | RELLENO Y COMPACTACION MANUAL DE ZANJAS C/ MATERIAL PROPIO CON EQUIPO 100 x 100 cm | 4d | 2022-08-04 | 2022-08-08 | 315 | 46d |  |
| 303 | 4.2 | **CONDUCTORES, DUCTOS Y ACCESORIOS** | 61d | 2022-05-25 | 2022-08-03 |  | 50d |  |
| 304 | 4.2.1 | CONDUCTOR DE Cu DE 1-1x10mm2 N2XOH BLANCO | 1d | 2022-08-03 | 2022-08-03 | 106FF | 50d |  |
| 305 | 4.2.2 | CONDUCTOR DE Cu DE 2.5 mm2 NH-80 VERDE | 2d | 2022-08-02 | 2022-08-03 | 106FF | 50d |  |
| 306 | 4.2.3 | CONDUCTOR DE Cu DE 2.5 mm2 NH-80 BLANCO | 4d | 2022-07-30 | 2022-08-03 | 106FF | 50d |  |
| 307 | 4.2.4 | CONDUCTOR DE Cu DE 2.5 mm2 NH-80 NEGRO | 4d | 2022-07-30 | 2022-08-03 | 106FF | 50d |  |
| 308 | 4.2.5 | CONDUCTOR DE Cu DE 4 mm2 NH-80 BLANCO | 1d | 2022-08-03 | 2022-08-03 | 106FF | 50d |  |
| 309 | 4.2.6 | CONDUCTOR DE Cu DE 4 mm2 NH-80 NEGRO | 1d | 2022-08-03 | 2022-08-03 | 106FF | 50d |  |
| 310 | 4.2.7 | CONDUCTOR DE Cu DE 4 mm2 NH-80 VERDE | 1d | 2022-08-03 | 2022-08-03 | 106FF | 50d |  |
| 311 | 4.2.8 | CONDUCTOR DE Cu DE 10 mm2 NH-80 VERDE | 1d | 2022-08-03 | 2022-08-03 | 106FF | 50d |  |
| 312 | 4.2.9 | CONDUCTOR DE Cu DESNUDO DE 35mm2 | 1d | 2022-08-03 | 2022-08-03 | 106FF | 50d |  |
| 313 | 4.2.10 | TUBERIA PVC-SAP DE 20 MM DE DIAMETRO INC. ACCESORIOS | 4d | 2022-07-30 | 2022-08-03 | 106FF | 50d |  |
| 314 | 4.2.11 | TUBERIA PVC-SAP DE 25 MM DE DIAMETRO INC. ACCESORIOS | 1d | 2022-08-03 | 2022-08-03 | 106FF | 50d |  |
| 315 | 4.2.12 | TUBERIA PVC-SAP DE 35 MM DE DIAMETRO INC. ACCESORIOS | 1d | 2022-08-03 | 2022-08-03 | 106FF | 46d | 0d |
| 316 | 4.2.13 | CAJA DE DERIVACION DE 200x200x150 | 1d | 2022-05-25 | 2022-05-25 | 300 | 110d |  |
| 317 | 4.2.14 | SISTEMA DE TUBERIA CONDUIT EMT INC. ACCESORIOS | 5d | 2022-07-29 | 2022-08-03 | 106FF | 50d |  |

| ID | WBS | Task | Duration | Start | Finish | Predecessors | Total slack | Free slack |
| --- | --- | --- | --- | --- | --- | --- | --- | --- |
| 318 | 4.3 | **ARTEFACTOS DE ILUMINACION - LUMINARIAS / TOMACORRIENTES** | 51d | 2022-08-02 | 2022-09-29 |  | 1d |  |
| 319 | 4.3.1 | SmartLED Office W60L60 - PHILLIPS (LUMINARIA ADOSADA) 4 LAMPARAS | 4d | 2022-09-14 | 2022-09-17 | 208 | 1d | 0d |
| 320 | 4.3.2 | SmartLED Office W30L120 - PHILLIPS (LUMINARIA ADOSADA) 2 LAMPARAS | 2d | 2022-09-19 | 2022-09-20 | 319 | 1d | 0d |
| 321 | 4.3.3 | INDIKO FORYIMO LED - PHILLIPS (LUMINARIA HERMÉTICA) 2 LAMPARA | 2d | 2022-09-21 | 2022-09-22 | 320 | 1d | 0d |
| 322 | 4.3.4 | BERYL ADOSADA LED 15W | 1d | 2022-09-23 | 2022-09-23 | 321 | 1d | 0d |
| 323 | 4.3.5 | LAMPARA DE EMERGENCIA DE 24 LEDS | 1d | 2022-09-24 | 2022-09-24 | 322 | 1d | 0d |
| 324 | 4.3.6 | Reflector Josfel Hall Ligth Led 250W asimétrico o EQUIVALENTE | 2d | 2022-09-26 | 2022-09-27 | 323 | 1d | 0d |
| 325 | 4.3.7 | DICROICO PARA PISO | 2d | 2022-09-28 | 2022-09-29 | 324 | 1d |  |
| 326 | 4.3.8 | CAJA OCTOGONAL F°G° DE 100mm x 55mm | 2d | 2022-08-02 | 2022-08-03 | 106FF | 50d |  |
| 327 | 4.3.9 | INTERRUPTOR SIMPLE UNIPOLAR | 1d | 2022-09-14 | 2022-09-14 | 208 | 9d | 0d |
| 328 | 4.3.10 | INTERRUPTOR DOBLE UNIPOLAR | 1d | 2022-09-15 | 2022-09-15 | 327 | 9d | 0d |
| 329 | 4.3.11 | INTERRUPTOR TRIPLE UNIPOLAR | 1d | 2022-09-16 | 2022-09-16 | 328 | 9d | 0d |
| 330 | 4.3.12 | INTERRUPTOR DE CONMUTACION SIMPLE | 1d | 2022-09-17 | 2022-09-17 | 329 | 9d | 0d |
| 331 | 4.3.13 | TOMACORRIENTE DOBLE C/T | 1d | 2022-09-19 | 2022-09-19 | 330 | 9d | 0d |
| 332 | 4.3.14 | CAJA RECTANGULAR F°G° DE 100 x 55 x 50mm | 1d | 2022-08-03 | 2022-08-03 | 106FF | 50d |  |
| 333 | 4.3.15 | TIMBRE (CHICHARRA) + PULSADOR | 1d | 2022-09-20 | 2022-09-20 | 331 | 9d |  |
| 334 | 4.4 | **TABLERO ELECTRICO TRIFASICO/ MONOFASICO** | 2d | 2022-09-08 | 2022-09-09 |  | 17d |  |
| 335 | 4.4.1 | TABLERO ELECTRICO DE F°G° EMPOTRADO 8 POLOS | 1d | 2022-09-08 | 2022-09-08 | 207 | 17d | 0d |
| 336 | 4.4.2 | TABLERO ELECTRICO DE F°G° EMPOTRADO 18 POLOS | 1d | 2022-09-09 | 2022-09-09 | 335 | 17d | 0d |
| 337 | 4.5 | **INTERRUPTORES TERMOMAGNETICOS MONOFASICOS** | 1d | 2022-09-09 | 2022-09-09 |  | 18d |  |
| 338 | 4.5.1 | INTERRUPTOR THERMOMAGNETICO MONOFASICO 2 X 15A | 1d | 2022-09-09 | 2022-09-09 | 335 | 18d |  |
| 339 | 4.5.2 | INTERRUPTOR THERMOMAGNETICO MONOFASICO 2 X 35A | 1d | 2022-09-09 | 2022-09-09 | 335 | 18d |  |
| 340 | 4.6 | **INTERRUPTORES DIFERENCIALES** | 1d | 2022-09-10 | 2022-09-10 |  | 17d |  |
| 341 | 4.6.1 | INTERRUPTOR DIFERENCIAL 2x20 A/30mm A | 1d | 2022-09-10 | 2022-09-10 | 336 | 17d |  |
| 342 | 4.6.2 | INTERRUPTOR DIFERENCIAL 2x25 A/30mm A | 1d | 2022-09-10 | 2022-09-10 | 336 | 17d |  |

| ID | WBS | Task | Type | Duration | Start | Finish | Predecessors | Total slack | Free slack |
| --- | --- | --- | --- | --- | --- | --- | --- | --- | --- |
| 343 | 4.7 | **CIRCUITOS DE MANDO DE ILUMINACION DE PATIOS** |  | 1d | 2022-09-10 | 2022-09-10 |  | 17d |  |
| 344 | 4.7.1 | PULSADOR LUMINOSO NA 220V IP66 |  | 1d | 2022-09-10 | 2022-09-10 | 336 | 17d |  |
| 345 | 4.7.2 | CONTACTOR TRIFASICO 25A |  | 1d | 2022-09-10 | 2022-09-10 | 336 | 17d |  |
| 346 | 4.8 | **PUESTA A TIERRA DE TABLERO GENERAL** |  | 8d | 2022-05-25 | 2022-06-02 |  | 103d |  |
| 347 | 4.8.1 | POZO CONEXION A TIERRA |  | 8d | 2022-05-25 | 2022-06-02 | 300 | 103d |  |
| 348 | 4.9 | **BUZON ELECTRICO** |  | 1d | 2022-05-25 | 2022-05-25 |  | 110d |  |
| 349 | 4.9.1 | BUZON DEL SISTEMA ELECTRICO 1.00x1.00x0.8 |  | 1d | 2022-05-25 | 2022-05-25 | 300 | 110d |  |
| 350 | 4.10 | **ELECTROBOMBA** |  | 1d | 2022-09-10 | 2022-09-10 |  | 17d |  |
| 351 | 4.10.1 | TABLERO DE ELECTROBOMBAS |  | 1d | 2022-09-10 | 2022-09-10 | 336 | 17d |  |
| 352 | 4.11 | **TRANSPORTE DE MATERIALES** |  | 1d | 2022-05-04 | 2022-05-04 |  | 128d |  |
| 353 | 4.11.1 | TRANSPORTE DE MATERIALES (3% DE MATERIALES) |  | 1d | 2022-05-04 | 2022-05-04 | 3 | 128d |  |
| 354 | 4.12 | **COMUNICACIONES** |  | 22d | 2022-05-02 | 2022-05-26 |  | 109d |  |
| 355 | 4.12.1 | TUBERIA PVC-SAP DE 25 MM DE DIAMETRO INC. ACCESORIOS |  | 1d | 2022-05-02 | 2022-05-02 |  | 130d |  |
| 356 | 4.12.2 | CAJA DE DERIVACION DE 200x200x150 |  | 1d | 2022-05-25 | 2022-05-25 | 300 | 109d | 0d |
| 357 | 4.12.3 | CAJA RECTANGULAR F°G° DE 100 x 55 x 50mm |  | 1d | 2022-05-26 | 2022-05-26 | 356 | 109d |  |
| 358 | 4.13 | **CONEXION Y ADECUACION A RED DE ENERGIA EXISTENTE** |  | 4d | 2022-08-04 | 2022-08-08 |  | 46d |  |
| 359 | 4.13.1 | CONEXION Y ADECUACION A RED DE ENERGIA EXISTENTE (incluye todas las gestiones necesarias) |  | 4d | 2022-08-04 | 2022-08-08 | 106 | 46d |  |
| 360 | 5 | CONTINGENCIA |  | 10d | 2022-05-02 | 2022-05-12 | 3SS | 121d |  |
| 361 | 6 | MOBILIARIO Y EQUIPAMIENTO | manual | 11d | 2022-09-14 | 2022-09-26 | 208 |  |  |
